# DISEÑO, ENSAMBLE Y PUESTA EN FUNCIONAMIENTO DE DEPOSITO COLECTOR DE RESIDUOS SÓLIDOS AUTOMATIZADO

Schedule from MS Project, 2020-01-20 to 2021-01-12, status date 2020-06-16, costs in $, A marks actual dates.

## Calendars

- Calendario del proyecto: Mon-Fri 07:00-12:00, 14:00-17:00; Sat-Sun off. Exceptions (off unless hours are given): 2020-03-23 (Festivo 1), 2020-04-09 (Festivo 2), 2020-05-01 (Festivo 4), 2020-05-10 (Festivo 3), 2020-05-25 (Festivo 5), 2020-06-15 (Festivo 6), 2020-06-22 (Festivo 7), 2020-06-29 (Festivo 8), 2020-07-20 (Festivo 9), 2020-08-07 (Festivo 10), 2020-08-17 (Festivo 11).

## Resources

| Resource | Unit | Rate |
| --- | --- | --- |
| Computador 1 | Unidad | 2500 |
| Impresora 2 | Unidad | 1000 |
| Papeleria | unidad | 12000 |
| Deposito redondo tapa negra 30 Litros Pedal Home colection - Homecenter. | unidad | 99900 |
| Cable UTP x metro | unidad | 1000 |
| Cable polarizado x metro | unidad | 1200 |
| Servomotor | unidad | 59500 |
| Conector db9 caja | unidad | 1500 |
| Cinta gap 4 pines | unidad | 2500 |
| Cinta DuPont x metro | unidad | 8000 |
| Sensor ultrasonido | unidad | 12000 |
| Arduino mega 2560 | unidad | 45000 |
| Pantalla táctil mega | unidad | 41000 |
| Conectores plug | unidad | 1000 |
| Fuente de poder | unidad | 50000 |
| Conectores stero | unidad | 1000 |
| Jack de chasis | unidad | 800 |
| Jack aéreo | unidad | 500 |
| Pegante SIKAFLEX | unidad | 9500 |
| Impresión 3D Caja ultrasonido | unidad | 92000 |
| Diseño y fabricación de resorte para apertura | unidad | 22000 |
| Caja negra circuito electrónico | unidad | 15000 |
| Diseño y fabricación impresión 3D para Soporte del servomotor | unidad | 25000 |
| Impresión 3D de Leva para el mecanismo de apertura. | unidad | 25000 |
| Soporte de Acero Inoxidable | unidad | 300000 |
| Acrílico (Logotipo) | unidad | 65000 |
| Tornillos Driwall (Soporte-acrílico) | unidad | 50 |
| Tapones de estanqueidad (Soporte) | unidad | 2525 |
| Ingeniero electromecanico 1 |  | 13000 |
| Dibujante 1 |  | 8000 |
| Ingeniero electronico 1 |  | 13000 |
| Auxiliar tecnico 1 |  | 7000 |
| Director de proyecto |  | 20000 |
| Ingeniero electronico 2 |  | 13000 |
| Auxiliar tecnico 2 |  | 7000 |
| Ingeniero electromecanico 2 |  | 13000 |
| Auxiliar tecnico 3 |  | 7000 |
| Impresora 1 |  | 1000 |
| Computador 2 |  | 2500 |
| Computador 4 |  | 2500 |
| Computador 3 |  | 2500 |
| Computador 5 |  | 2500 |
| Dibujante 2 |  |  |

## Schedule

| ID | WBS | Task | Duration | Start | Finish | Predecessors | Complete | Remaining | Baseline start | Baseline finish | Baseline duration | Total slack | Free slack | Resources | Work | Actual work | Cost | Baseline cost | Actual cost |
| --- | --- | --- | --- | --- | --- | --- | --- | --- | --- | --- | --- | --- | --- | --- | --- | --- | --- | --- | --- |
| 1 | 1 | **Gerencia proyecto** | 246d | 2020-01-20 A | 2021-01-12 |  | 48% | 128.21d | 2020-01-20 | 2021-01-07 | 243d | 0d |  |  | 596h | 387.8h | 5,641,000 | 6,366,000 | 3,799,600 |
| 2 | 1.1 | **Inicio** | 4d | 2020-01-20 A | 2020-01-24 A |  | 100% |  | 2020-01-20 | 2020-01-24 | 4d |  |  |  | 96h | 96h | 750,000 | 776,000 | 750,000 |
| 3 | 1.1.1 | Conformar acta de constitución | 2d | 2020-01-20 A | 2020-01-22 A |  | 100% |  | 2020-01-20 | 2020-01-22 | 2d |  |  | Computador 1 [1 Unidad]; Papeleria [1 unidad]; Director de proyecto; Impresora 1 | 48h | 48h | 350,000 | 388,000 | 350,000 |
| 4 | 1.1.2 | Generar registro de interesados | 2d | 2020-01-22 A | 2020-01-24 A | 3 | 100% |  | 2020-01-22 | 2020-01-24 | 2d |  |  | Computador 1 [1 Unidad]; Director de proyecto; Papeleria [1 unidad]; Impresora 1 | 48h | 48h | 400,000 | 388,000 | 400,000 |
| 5 | 1.2 | **Planificación** | 4d | 2020-01-24 A | 2020-01-30 |  | 93% | 0.27d | 2020-01-24 | 2020-01-30 | 4d | 238d |  |  | 128h | 121.6h | 891,000 | 878,000 | 858,000 |
| 6 | 1.2.1 | Refinar y ajustar objetivos finales del proyecto | 2d | 2020-01-24 A | 2020-01-28 A | 4 | 100% |  | 2020-01-24 | 2020-01-28 | 2d |  |  | Ingeniero electromecanico 2; Papeleria [0.5 unidad]; Impresora 2 [1 Unidad]; Computador 1 [1 Unidad] | 48h | 48h | 270,000 | 270,000 | 270,000 |
| 7 | 1.2.2 | Definir el alcance en forma detallada | 2d | 2020-01-28 A | 2020-01-30 A | 6 | 100% |  | 2020-01-28 | 2020-01-30 | 2d |  |  | Ingeniero electromecanico 2; Ingeniero electronico 2; Computador 2 | 48h | 48h | 456,000 | 456,000 | 456,000 |
| 8 | 1.2.3 | Solicitud de cambios | 2d | 2020-01-24 A | 2020-01-28 | 4 | 80% | 0.4d | 2020-01-24 | 2020-01-28 | 2d | 240d |  | Auxiliar tecnico 1; Computador 2 | 32h | 25.6h | 165,000 | 152,000 | 132,000 |
| 9 | 1.3 | **Seguimiento y control** | 24d | 2020-01-24 A | 2020-02-27 |  | 75% | 6.1d | 2020-01-24 | 2020-02-26 | 23d | 218d |  |  | 228h | 170.2h | 2,980,000 | 2,880,000 | 2,191,600 |
| 10 | 1.3.1 | Verificar el desempeño del proyecto | 7d | 2020-02-04 A | 2020-02-13 | 22 | 75% | 1.75d | 2020-02-04 | 2020-02-13 | 7d | 2.4d | 0d | Ingeniero electromecanico 1; Director de proyecto [50%] | 84h | 63h | 1,280,000 | 1,288,000 | 958,000 |
| 11 | 1.3.2 | Análizar los datos obtenidos y variaciones presentadas | 10d | 2020-02-13 A | 2020-02-27 | 10 | 63% | 3.7d | 2020-02-13 | 2020-02-26 | 9d | 218d |  | Ingeniero electromecanico 1 | 80h | 50.4h | 1,204,000 | 936,000 | 819,200 |
| 12 | 1.3.3 | Elaborar informes de desempeño | 3d | 2020-02-13 A | 2020-02-18 | 10 | 80% | 0.6d | 2020-02-13 | 2020-02-18 | 3d | 225d |  | Auxiliar tecnico 1 | 24h | 19.2h | 118,000 | 168,000 | 84,400 |
| 13 | 1.3.4 | Socializar la información a los interesados | 3d | 2020-01-24 A | 2020-01-29 A | 4 | 100% |  | 2020-01-24 | 2020-01-29 | 3d |  |  | Auxiliar tecnico 2 | 24h | 24h | 168,000 | 168,000 | 168,000 |
| 14 | 1.3.5 | Solicitud de cambios | 2d | 2020-01-29 A | 2020-01-31 | 13 | 85% | 0.3d | 2020-01-29 | 2020-01-31 | 2d | 237d |  | Director de proyecto | 16h | 13.6h | 210,000 | 320,000 | 162,000 |
| 15 | 1.4 | **Cierre** | 24d | 2020-12-09 | 2021-01-12 |  |  |  | 2020-12-09 | 2021-01-07 | 21d | 0d |  |  | 144h |  | 1,020,000 | 1,832,000 |  |
| 16 | 1.4.1 | Verificar finalización procesos | 6d | 2020-12-09 | 2020-12-17 | 51 |  |  | 2020-12-09 | 2020-12-17 | 6d | 0d |  | Ingeniero electromecanico 1 | 48h |  | 500,000 | 624,000 |  |
| 17 | 1.4.2 | Transferir y entregar los depósitos a la Universidad sede Neiva | 6d | 2020-12-17 | 2020-12-25 | 16 |  |  | 2020-12-17 | 2020-12-23 | 4d | 0d |  | Director de proyecto | 48h |  | 320,000 | 640,000 |  |
| 18 | 1.4.3 | Compilar las lecciones aprendidas | 6d | 2020-12-25 | 2021-01-04 | 17 |  |  | 2020-12-23 | 2020-12-30 | 5d | 0d |  | Director de proyecto [50%] | 24h |  | 80,000 | 400,000 |  |
| 19 | 1.4.4 | Generar informe de cierre | 6d | 2021-01-04 | 2021-01-12 | 18 |  |  | 2020-12-30 | 2021-01-07 | 6d | 0d |  | Auxiliar tecnico 1 [50%] | 24h |  | 120,000 | 168,000 |  |
| 20 | 2 | **Ejecución** | 246d | 2020-01-20 A | 2021-01-12 |  | 25% | 184.35d | 2020-01-20 | 2021-01-08 | 244d | 0d |  |  | 5682.4h | 1458.92h | 68,610,000 | 72,304,300 | 9,009,640 |
| 21 | 2.1 | **Diseño** | 44d | 2020-01-28 A | 2020-03-31 A |  | 100% |  | 2020-01-28 | 2020-03-31 | 44d |  |  |  | 948h | 948h | 5,280,000 | 5,488,000 | 5,280,000 |
| 22 | 2.1.1 | Diagramar el diseño preliminar de los colectores | 5d | 2020-01-28 A | 2020-02-04 A | 8 | 100% |  | 2020-01-28 | 2020-02-04 | 5d |  |  | Ingeniero electromecanico 1 [50%]; Ingeniero electronico 1; Auxiliar tecnico 3; Computador 3; Computador 4; Computador 5 | 220h | 220h | 1,400,000 | 1,360,000 | 1,400,000 |
| 23 | 2.1.2 | Ajustar los diseños preliminares | 8d | 2020-02-04 A | 2020-02-14 A | 22 | 100% |  | 2020-02-04 | 2020-02-14 | 8d |  |  | Auxiliar tecnico 2; Ingeniero electromecanico 2 | 128h | 128h | 1,100,000 | 1,280,000 | 1,100,000 |
| 24 | 2.1.3 | Aprobar diseños preliminares | 4d | 2020-02-14 A | 2020-02-20 A | 23 | 100% |  | 2020-02-14 | 2020-02-20 | 4d |  |  | Director de proyecto [50%] | 16h | 16h | 280,000 | 320,000 | 280,000 |
| 25 | 2.1.4 | Definir especificaciones técnicas (ingeniería en detalle) | 5d | 2020-02-20 A | 2020-02-27 A | 24 | 100% |  | 2020-02-20 | 2020-02-27 | 5d |  |  | Auxiliar tecnico 2; Ingeniero electronico 2 [50%]; Computador 4; Computador 5 | 140h | 140h | 700,000 | 740,000 | 700,000 |
| 26 | 2.1.5 | Aprobar especificaciones técnicas (ingeniería en detalle) | 2d | 2020-02-27 A | 2020-03-02 A | 25 | 100% |  | 2020-02-27 | 2020-03-02 | 2d |  |  | Ingeniero electromecanico 1 [50%] | 8h | 8h | 80,000 | 104,000 | 80,000 |
| 27 | 2.1.6 | Realizar planos definitivos | 12d | 2020-03-02 A | 2020-03-18 A | 26 | 100% |  | 2020-03-02 | 2020-03-18 | 12d |  |  | Dibujante 1; Dibujante 2; Computador 1 [1 Unidad]; Computador 2 | 384h | 384h | 1,280,000 | 1,248,000 | 1,280,000 |
| 28 | 2.1.7 | Aprobar especificaciones técnicas y planos de los contenedores | 3d | 2020-03-18 A | 2020-03-24 A | 27 | 100% |  | 2020-03-18 | 2020-03-24 | 3d |  |  | Ingeniero electromecanico 1 [50%] | 12h | 12h | 160,000 | 156,000 | 160,000 |
| 29 | 2.1.8 | Distribuir especificaciones técnicas y planos de los contenedores | 5d | 2020-03-24 A | 2020-03-31 A | 28 | 100% |  | 2020-03-24 | 2020-03-31 | 5d |  |  | Auxiliar tecnico 3 | 40h | 40h | 280,000 | 280,000 | 280,000 |

| ID | WBS | Task | Type | Duration | Start | Finish | Predecessors | Complete | Remaining | Baseline start | Baseline finish | Baseline duration | Total slack | Free slack | Resources | Work | Actual work | Cost | Baseline cost | Actual cost |
| --- | --- | --- | --- | --- | --- | --- | --- | --- | --- | --- | --- | --- | --- | --- | --- | --- | --- | --- | --- | --- |
| 30 | 2.2 | **Compras** |  | 56d | 2020-03-02 A | 2020-05-22 |  | 94% | 3.38d | 2020-03-02 | 2020-05-22 | 56d | 160d |  |  | 436.8h | 422.72h | 2,838,000 | 3,089,600 | 2,739,440 |
| 31 | 2.2.1 | Identificar proveedores (principales y contingentes) |  | 9d | 2020-03-02 A | 2020-03-13 A | 26 | 100% |  | 2020-03-02 | 2020-03-13 | 9d |  |  | Impresora 1; Ingeniero electronico 1; Computador 3 | 216h | 216h | 1,188,000 | 1,188,000 | 1,188,000 |
| 32 | 2.2.2 | Aprobar y contratar con proveedores (principales y contingentes) |  | 3d | 2020-03-13 A | 2020-03-18 A | 31 | 100% |  | 2020-03-13 | 2020-03-18 | 3d |  |  | Ingeniero electromecanico 1 [50%] | 12h | 12h | 150,000 | 156,000 | 150,000 |
| 33 | 2.2.3 | Apobar presupo |  | 5d | 2020-03-18 A | 2020-03-26 A | 32 | 100% |  | 2020-03-18 | 2020-03-26 | 5d |  |  | Director de proyecto [50%] | 20h | 20h | 400,000 | 400,000 | 400,000 |
| 34 | 2.2.4 | Generar ordenes de compra |  | 2d | 2020-03-31 A | 2020-04-02 A | 33, 29 | 100% |  | 2020-03-31 | 2020-04-02 | 2d |  |  | Computador 4; Ingeniero electromecanico 1 | 32h | 32h | 190,000 | 248,000 | 190,000 |
| 35 | 2.2.5 | Adquirir diferentes componentes y materias primas |  | 10d | 2020-04-02 A | 2020-04-17 | 34 | 95% | 0.5d | 2020-04-02 | 2020-04-17 | 10d | 5.1d | 0d | Auxiliar tecnico 3 | 80h | 76h | 490,000 | 560,000 | 462,000 |
| 36 | 2.2.6 | Control de calidad componentes y materias primas |  | 6d | 2020-04-17 A | 2020-04-27 | 35 | 85% | 0.9d | 2020-04-17 | 2020-04-27 | 6d | 16.2d | 0d | Auxiliar tecnico 3 | 48h | 40.8h | 280,000 | 336,000 | 229,600 |
| 37 | 2.2.7 | Entregar componentes y materias primas al almacén para su custodia |  | 18d | 2020-04-27 A | 2020-05-22 | 36 | 90% | 1.8d | 2020-04-27 | 2020-05-22 | 18d | 160d |  | Auxiliar tecnico 3 [20%] | 28.8h | 25.92h | 140,000 | 201,600 | 119,840 |
| 38 | 2.3 | **Montaje** |  | 103d | 2020-05-22 A | 2020-10-23 |  | 5% | 98.19d | 2020-05-22 | 2020-10-23 | 103d | 57d |  |  | 2889.6h | 88.2h | 44,735,000 | 45,131,700 | 990,200 |
| 39 | 2.3.1 | Generar solicitudes de liberación de los componentes y materias primas al almacén |  | 2d | 2020-05-22 A | 2020-05-27 A | 37 | 100% |  | 2020-05-22 | 2020-05-27 | 2d |  |  | Auxiliar tecnico 3 [10%] | 1.6h | 1.6h | 10,000 | 11,200 | 10,000 |
| 40 | 2.3.2 | Recepcionar componentes y materias primas por montajes |  | 2d | 2020-05-27 A | 2020-05-29 | 39 | 95% | 0.1d | 2020-05-27 | 2020-05-29 | 2d | 3.29d | 0d | Auxiliar tecnico 2 [50%] | 8h | 7.6h | 45,000 | 56,000 | 42,200 |
| 41 | 2.3.3 | Fabricar soportes y levas de apertura en impresora 3D |  | 30d | 2020-05-29 A | 2020-07-15 | 40 | 11% | 26.71d | 2020-05-29 | 2020-07-15 | 30d | 0d |  | Ingeniero electromecanico 1; Auxiliar tecnico 1; Auxiliar tecnico 2; Diseño y fabricación de resorte para apertura [45 unidad] | 720h | 79h | 7,400,000 | 7,470,000 | 938,000 |
| 42 | 2.3.4 | Ensamblar soportes y sistema de llenado en el contenedor |  | 34d | 2020-07-15 | 2020-09-04 | 41 |  |  | 2020-07-15 | 2020-09-04 | 34d | 0d |  | Ingeniero electromecanico 2 [50%]; Auxiliar tecnico 3; Ingeniero electronico 1; Deposito redondo tapa negra 30 Litros Pedal Home colection - Homecenter. [45 unidad]; Diseño y fabricación impresión 3D para Soporte del servomotor [45 unidad]; Soporte de Acero Inoxidable [1 unidad]; Tapones de estanqueidad (Soporte) [180 unidad]; Servomotor [45 unidad]; Sensor ultrasonido [90 unidad]; Pegante SIKAFLEX [45 unidad]; Jack de chasis [45 unidad]; Jack aéreo [45 unidad]; Cable polarizado x metro [45 unidad]; Cable UTP x metro [45 unidad]; Caja negra circuito electrónico [45 unidad]; Cinta DuPont x metro [45 unidad]; Cinta gap 4 pines [45 unidad]; Conector db9 caja [45 unidad]; Conectores plug [45 unidad]; Conectores stero [45 unidad] | 680h |  | 21,000,000 | 19,230,500 |  |
| 43 | 2.3.5 | Ensamblar sistema de apertura y cierre en el contenedor |  | 28d | 2020-07-15 | 2020-08-27 | 41 |  |  | 2020-07-15 | 2020-08-27 | 28d | 6d | 0d | Ingeniero electronico 2; Auxiliar tecnico 2; Computador 3; Ingeniero electromecanico 1 | 896h |  | 7,200,000 | 7,952,000 |  |
| 44 | 2.3.6 | Ejecutar control de calidad del montaje |  | 35d | 2020-09-04 | 2020-10-23 | 42, 43 |  |  | 2020-09-04 | 2020-10-23 | 35d | 57d |  | Ingeniero electronico 1 | 280h |  | 3,400,000 | 3,640,000 |  |
| 45 | 2.3.7 | Instalar sistemas de alimentación |  | 15d | 2020-09-04 | 2020-09-25 | 42, 43 |  |  | 2020-09-04 | 2020-09-25 | 15d | 0d |  | Ingeniero electronico 2; Auxiliar tecnico 1; Diseño y fabricación de resorte para apertura [45 unidad] | 240h |  | 2,900,000 | 3,390,000 |  |
| 46 | 2.3.8 | Instalar señalización |  | 8d | 2020-08-27 | 2020-09-08 | 43 |  |  | 2020-08-27 | 2020-09-08 | 8d | 13d |  | Auxiliar tecnico 2; Acrílico (Logotipo) [45 unidad]; Tornillos Driwall (Soporte-acrílico) [180 unidad] | 64h |  | 2,780,000 | 3,382,000 |  |
| 47 | 2.4 | **Programacion IDE** |  | 246d | 2020-01-20 | 2021-01-12 |  |  |  | 2020-01-20 | 2021-01-08 | 244d | 0d |  |  | 1408h |  | 15,757,000 | 18,595,000 |  |
| 48 | 2.4.1 | Programar componentes electrónicos con lenguaje IDE Arduino |  | 50d | 2020-09-25 | 2020-12-04 | 46, 45 |  |  | 2020-09-25 | 2020-12-04 | 50d | 0d |  | Auxiliar tecnico 1; Ingeniero electromecanico 2; Ingeniero electronico 2; Arduino mega 2560 [45 unidad] | 1200h |  | 14,700,000 | 15,225,000 |  |
| 49 | 2.4.2 | Probar funcionamiento sistema de apertura |  | 5d | 2020-12-04 | 2020-12-11 | 48 |  |  | 2020-12-04 | 2020-12-11 | 5d | 22d |  | Ingeniero electronico 1; Computador 1 [1 Unidad]; Impresora 1; Auxiliar tecnico 1 | 160h |  | 650,000 | 940,000 |  |
| 50 | 2.4.3 | Probar funcionamiento sistema de monitoreo |  | 3d | 2020-12-04 | 2020-12-09 | 48 |  |  | 2020-12-04 | 2020-12-09 | 3d | 24d |  | Auxiliar tecnico 2 | 24h |  | 127,000 | 168,000 |  |
| 51 | 2.4.4 | Probar funcionamiento sistema de pantallas |  | 3d | 2020-12-04 | 2020-12-09 | 48 |  |  | 2020-12-04 | 2020-12-09 | 3d | 0d |  | Ingeniero electronico 2 | 24h |  | 280,000 | 312,000 |  |
| 52 | 2.4.5 | Reserva de contingencia |  | 91d | 2020-01-20 | 2020-06-01 |  |  |  | 2020-01-20 | 2021-01-08 | 244d | 155d |  |  |  |  |  | 1,950,000 |  |
| 53 | 2.4.6 | FIN | milestone | 0d | 2021-01-12 | 2021-01-12 | 7, 14, 11, 12, 44, 19, 50, 49 |  |  | 2021-01-07 | 2021-01-07 | 0d | 0d |  |  |  |  |  |  |  |
